# CRONOGRAMA GANTT

Schedule from MS Project, 2022-05-02 to 2022-08-31.

## Calendars

- SEMANAL: Mon-Sat 08:00-13:00, 14:00-17:00; Sun off.

## Schedule

| ID | WBS | Task | Duration | Start | Finish | Predecessors | Total slack | Free slack |
| --- | --- | --- | --- | --- | --- | --- | --- | --- |
| 1 | 1 | **ESTRUCTURAS** | 92d | 2022-05-02 | 2022-08-16 |  | 0d |  |
| 2 | 1.1 | **OBRAS PROVISIONALES** | 16d | 2022-05-02 | 2022-05-19 |  | 13d |  |
| 3 | 1.1.1 | ALMACÉN, OFICINAS | 2d | 2022-05-02 | 2022-05-03 |  | 9d | 0d |
| 4 | 1.1.2 | CARTEL DE OBRA DE 3.60 X 2.40 m | 1d | 2022-05-02 | 2022-05-02 | 3SS | 130d |  |
| 5 | 1.1.3 | CERCO PROVISIONAL DE OBRA | 1d | 2022-05-02 | 2022-05-02 | 3SS | 130d |  |
| 6 | 1.1.4 | SERVICIOS HIGIÉNICOS | 1d | 2022-05-04 | 2022-05-04 | 3 | 128d |  |
| 7 | 1.1.5 | ELABORACION, IMPLEMENTACION Y ADMINISTRACION DEL PLAN DE SEGURIDAD Y SALUD EN EL TRABAJO | 2d | 2022-05-02 | 2022-05-03 | 3SS | 129d | 0d |
| 8 | 1.1.6 | SUMINISTRO DE DEPOSITOS DE BASURA | 1d | 2022-05-04 | 2022-05-04 | 3 | 128d |  |
| 9 | 1.1.7 | SUMINISTRO DE IMPLEMENTOS DE SEGURIDAD | 1d | 2022-05-04 | 2022-05-04 | 3 | 128d |  |
| 10 | 1.1.8 | SEÑALIZACION TEMPORAL AMBIENTAL Y SEGURIDAD | 14d | 2022-05-04 | 2022-05-19 | 3 | 111d |  |
| 11 | 1.2 | **TRABAJOS PRELIMINARES** | 92d | 2022-05-02 | 2022-08-16 |  | 13d |  |
| 12 | 1.2.1 | TRAZO Y REPLANTEO PRELIMINAR Y CONTROL PERMANENTE DE OBRA | 1d | 2022-05-04 | 2022-05-04 | 3 | 5d | 0d |
| 13 | 1.2.2 | LIMPIEZA PERMANENTE Y FINAL DE OBRA | 6d | 2022-05-04 | 2022-05-10 | 12SS | 119d |  |
| 14 | 1.2.3 | MOVILIZACION DE EQUIPO | 1d | 2022-05-04 | 2022-05-04 | 3 | 128d |  |
| 15 | 1.2.4 | **MITIGACION AMBIENTAL** | 12d | 2022-05-02 | 2022-05-14 |  | 93d |  |
| 16 | 1.2.4.1 | RIEGO DE TERRENO, MATERIAL EXCAVADO Y AGREGADOS | 10d | 2022-05-02 | 2022-05-12 | 51SS | 121d |  |
| 17 | 1.2.4.2 | PREVENCION DE DAÑOS - DERRAME DE COMBUSTIBLES | 10d | 2022-05-04 | 2022-05-14 | 3 | 119d |  |
| 18 | 1.2.5 | **DESMONTAJES** | 6d | 2022-05-04 | 2022-05-10 |  | 94d |  |
| 19 | 1.2.5.1 | DESMONTAJE DE VENTANAS | 1d | 2022-05-04 | 2022-05-04 | 12SS | 120d | 0d |
| 20 | 1.2.5.2 | DESMONTAJE DE PUERTAS | 1d | 2022-05-04 | 2022-05-04 | 19SS | 124d | 0d |
| 21 | 1.2.5.3 | DESMONTAJE DE MATERIAL PREFABRICADO (DRYWALL) | 6d | 2022-05-04 | 2022-05-10 | 19SS | 119d |  |
| 22 | 1.2.5.4 | DESMONTAJE DE TUBERIA DE DESAGUE | 1d | 2022-05-05 | 2022-05-05 | 19 | 116d | 0d |
| 23 | 1.2.5.5 | DESMONTAJE DE TANQUE ELEVADO Y SOPORTE METÁLICO | 1d | 2022-05-05 | 2022-05-05 | 22SS | 123d |  |
| 24 | 1.2.5.6 | DESMONTAJE DE APARATOS SANITARIOS | 1d | 2022-05-05 | 2022-05-05 | 22SS | 116d | 0d |
| 25 | 1.2.5.7 | DESMONTAJE DE COBERTURAS DE PLANCHAS DE FIBROCEMENTO (INC. LA ESTRUCTURA DE SOPORTE) | 3d | 2022-05-06 | 2022-05-09 | 24 | 116d | 0d |
| 26 | 1.2.5.8 | DESMONTAJE DE COBERTURA DE CALAMINA (INCLUYE ESTRUCTURA DE SOPORTE) | 3d | 2022-05-06 | 2022-05-09 | 25SS | 119d | 0d |
| 27 | 1.2.5.9 | DESMONTAJE DE PORTON ENTRADA PRINCIPAL | 1d | 2022-05-10 | 2022-05-10 | 26 | 119d |  |

| ID | WBS | Task | Duration | Start | Finish | Predecessors | Total slack | Free slack |
| --- | --- | --- | --- | --- | --- | --- | --- | --- |
| 28 | 1.2.6 | **DEMOLICIÓN , REMOCION Y RASQUETEO** | 7d | 2022-05-06 | 2022-05-13 |  | 94d |  |
| 29 | 1.2.6.1 | DEMOLICIÓN DE PISO INC. C.P.- F.P. | 3d | 2022-05-06 | 2022-05-09 | 24 | 116d | 0d |
| 30 | 1.2.6.2 | DEMOLICIÓN DE VEREDAS, PATIOS Y RAMPAS EXISTENTES | 4d | 2022-05-10 | 2022-05-13 | 29 | 116d |  |
| 31 | 1.2.6.3 | DEMOLICIÓN DE COLUMNAS DE CONCRETO | 1d | 2022-05-12 | 2022-05-12 | 33 | 116d | 0d |
| 32 | 1.2.6.4 | DEMOLICIÓN DE VIGAS DE CONCRETO | 1d | 2022-05-10 | 2022-05-10 | 25 | 116d | 0d |
| 33 | 1.2.6.5 | DEMOLICIÓN DE MUROS DE LADRILLO KK (SOGA Y DE CANTO) | 1d | 2022-05-11 | 2022-05-11 | 32 | 116d | 0d |
| 34 | 1.2.6.6 | DEMOLICIÓN DE CIMIENTOS DE CONCRETO | 1d | 2022-05-13 | 2022-05-13 | 31 | 116d |  |
| 35 | 1.2.7 | **DESMONTAJE DEL SISTEMA ELECTRICO** | 4d | 2022-05-05 | 2022-05-09 |  | 98d |  |
| 36 | 1.2.7.1 | DESMONTAJE DE CENTROS DE LUZ (INCLUYE INTERRUPTORES) | 1d | 2022-05-05 | 2022-05-05 | 20 | 120d | 0d |
| 37 | 1.2.7.2 | DESMONTAJE DE TOMACORRIENTES | 1d | 2022-05-06 | 2022-05-06 | 36 | 120d | 0d |
| 38 | 1.2.7.3 | DESMONTAJE DE CABLE DE CENTRO DE LUZ | 2d | 2022-05-07 | 2022-05-09 | 37 | 120d |  |
| 39 | 1.2.7.4 | DESMONTAJE DE CABLE PARA TOMACORRIENTES | 1d | 2022-05-07 | 2022-05-07 | 37 | 121d |  |
| 40 | 1.2.7.5 | DESMONTAJE DE TABLEROS | 1d | 2022-05-07 | 2022-05-07 | 37 | 121d |  |
| 41 | 1.2.8 | **PLAN PARA VIGILANCIA, PREVENCION Y CONTROL DE COVID 19, PARA EL TRABAJO** | 92d | 2022-05-02 | 2022-08-16 |  | 13d |  |
| 42 | 1.2.8.1 | ELABORACION DEL PLAN DE VIGILANCIA Y CONTROL COVID 19 | 1d | 2022-05-02 | 2022-05-02 | 7SS | 126d |  |
| 43 | 1.2.8.2 | LIMPIEZA Y DESINFECCION DE CENTRO DE TRABAJO | 90d | 2022-05-04 | 2022-08-16 | 12SS | 34d | 0d |
| 44 | 1.2.8.3 | EVALUACION DE LA CONDICION DE SALUD DEL TRABAJADOR PREVIO AL REGRESO E INCORPORACION AL CENTRO DE TRABAJO | 90d | 2022-05-04 | 2022-08-16 | 43SS | 34d | 0d |
| 45 | 1.2.8.4 | LAVADO Y DESINFECCION DE MANOS OBLIGATORIA | 90d | 2022-05-04 | 2022-08-16 | 44SS | 34d | 0d |
| 46 | 1.2.8.5 | SENSIBILIZACION DE LA PREVENCION DEL CONTAGIO EN EL CENTRO DE TRABAJO | 1d | 2022-05-04 | 2022-05-04 | 45SS | 121d | 0d |
| 47 | 1.2.8.6 | MEDIDAS PREVENTIVAS DE APLICACION COLECTIVA | 1d | 2022-05-04 | 2022-05-04 | 46SS | 121d | 0d |
| 48 | 1.2.8.7 | MEDIDAS DE PROTECCION PERSONAL | 4d | 2022-05-04 | 2022-05-07 | 47SS | 121d |  |
| 49 | 1.3 | **MOVIMIENTO DE TIERRAS** | 40d | 2022-05-02 | 2022-06-16 |  | 0d |  |
| 50 | 1.3.1 | **CORTE Y EXCAVACION** | 11d | 2022-05-02 | 2022-05-13 |  | 0d |  |
| 51 | 1.3.1.1 | EXCAVACION DE ZANJAS PARA CIMENTACION (CIMIENTOS CORRIDOS , PLATEAS Y ZAPATAS) | 11d | 2022-05-02 | 2022-05-13 |  | 0d |  |
| 52 | 1.3.1.2 | CORTE DE MATERIAL SUELTO R=150 m3/dia (EQUIPO) | 1d | 2022-05-05 | 2022-05-05 | 12 | 117d | 0d |

| ID | WBS | Task | Duration | Start | Finish | Predecessors | Total slack | Free slack |
| --- | --- | --- | --- | --- | --- | --- | --- | --- |
| 53 | 1.3.2 | **RELLENO** | 9d | 2022-06-07 | 2022-06-16 |  | 59d |  |
| 54 | 1.3.2.1 | RELLENO COMPACTADO MANUAL MATERIAL PROPIO | 7d | 2022-06-07 | 2022-06-14 | 79 | 61d | 0d |
| 55 | 1.3.2.2 | RELLENO COMPACTADO MANUAL MATERIAL DE PRESTAMO (AFIRMADO PREPARADO) | 1d | 2022-06-15 | 2022-06-15 | 54 | 61d | 0d |
| 56 | 1.3.2.3 | RELLENO COMPACTADO MANUAL MATERIAL DE PRESTAMO (HORMIGON) | 1d | 2022-06-16 | 2022-06-16 | 55 | 61d | 0d |
| 57 | 1.3.3 | **CONFORMACION,NIVELACION Y REFINE** | 3d | 2022-05-14 | 2022-05-17 |  | 0d |  |
| 58 | 1.3.3.1 | NIVELACION DE TERRENO Y COMPACTACION | 3d | 2022-05-14 | 2022-05-17 | 51 | 0d |  |
| 59 | 1.3.4 | **MEJORAMIENTO DE TERRENO** | 6d | 2022-05-06 | 2022-05-12 |  | 95d |  |
| 60 | 1.3.4.1 | MEJORAMIENTO DE TERRENO NATURAL e=50cm (COLOCACION DE OVER DE 1" A 6" - CON EQUIPO) | 1d | 2022-05-06 | 2022-05-06 | 52 | 117d | 0d |
| 61 | 1.3.4.2 | MEJORAMIENTO DE TERRENO NATURAL e=50cm (COLOCACION DE HORMIGON - CON EQUIPO) | 1d | 2022-05-07 | 2022-05-07 | 60 | 117d | 0d |
| 62 | 1.3.4.3 | MEJORAMIENTO DE TERRENO NATURAL e=30cm (COLOCACION DE HORMIGÓN - CON EQUIPO) | 1d | 2022-05-09 | 2022-05-09 | 61 | 117d | 0d |
| 63 | 1.3.4.4 | MEJORAMIENTO DE TERRENO NATURAL e=20cm (COLOCACION DE AFIRMADO MEJORADO) | 1d | 2022-05-10 | 2022-05-10 | 62 | 117d | 0d |
| 64 | 1.3.4.5 | MEJORAMIENTO DE TERRENO NATURAL e=10cm (COLOCACION DE AFIRMADO MEJORADO) | 2d | 2022-05-11 | 2022-05-12 | 63 | 117d |  |
| 65 | 1.3.5 | **ACARREO Y ELIMINACION DE MATERIAL** | 13d | 2022-05-02 | 2022-05-16 |  | 92d |  |
| 66 | 1.3.5.1 | ACARREO INTERNO MATERIAL PROCEDENTE DE EXCAVACIONES (Dprom=30m) | 13d | 2022-05-02 | 2022-05-16 | 51SS | 114d |  |
| 67 | 1.3.5.2 | ELIMINACION DE MATERIAL EXCEDENTE CON MAQUINARIA (Dprom=5 km) | 2d | 2022-05-12 | 2022-05-13 | 51FF | 96d |  |
| 68 | 1.4 | **CONCRETO SIMPLE** | 28d | 2022-05-18 | 2022-06-18 |  | 8d |  |
| 69 | 1.4.1 | **SOLADO** | 3d | 2022-05-18 | 2022-05-20 |  | 88d |  |
| 70 | 1.4.1.1 | SOLADO PARA VIGAS DE CIMENTACION e=2", 1:12 C/H | 3d | 2022-05-18 | 2022-05-20 | 58 | 90d |  |
| 71 | 1.4.1.2 | SOLADO PARA ZAPATA e=4", 1:12 C/H | 2d | 2022-05-18 | 2022-05-19 | 58 | 91d |  |
| 72 | 1.4.2 | **FALSO PISO** | 2d | 2022-06-17 | 2022-06-18 |  | 59d |  |
| 73 | 1.4.2.1 | FALSO PISO MEZCLA 1:8 e=4" | 2d | 2022-06-17 | 2022-06-18 | 56 | 61d | 0d |
| 74 | 1.4.3 | **CIMIENTOS** | 4d | 2022-05-27 | 2022-05-31 |  | 0d |  |
| 75 | 1.4.3.1 | CIMIENTOS CORRIDOS 1:10 + 30% P.G. FC=100 Kg/cm2 | 2d | 2022-05-30 | 2022-05-31 | 76 | 0d |  |
| 76 | 1.4.3.2 | CIMIENTOS CORRIDOS; ENCOFRADO Y DESENCOFRADO | 2d | 2022-05-27 | 2022-05-28 | 84 | 0d |  |

| ID | WBS | Task | Duration | Start | Finish | Predecessors | Total slack | Free slack |
| --- | --- | --- | --- | --- | --- | --- | --- | --- |
| 77 | 1.5 | **CONCRETO ARMADO** | 61d | 2022-05-05 | 2022-07-14 |  | 11d |  |
| 78 | 1.5.1 | **SOBRECIMIENTO** | 5d | 2022-06-01 | 2022-06-06 |  | 0d |  |
| 79 | 1.5.1.1 | SOBRECIMIENTOS.-CONCRETO f'c=175 kg/cm2 | 3d | 2022-06-03 | 2022-06-06 | 80SS+2d | 0d |  |
| 80 | 1.5.1.2 | SOBRECIMIENTO, ENCOFRADO Y DESENCOFRADO | 5d | 2022-06-01 | 2022-06-06 | 75 | 0d |  |
| 81 | 1.5.1.3 | SOBRECIMIENTO.-ACERO fy=4200 kg/cm2 | 5d | 2022-06-01 | 2022-06-06 | 80SS | 76d |  |
| 82 | 1.5.2 | **ZAPATAS** | 5d | 2022-05-24 | 2022-05-28 |  | 0d |  |
| 83 | 1.5.2.1 | ZAPATAS.-CONCRETO f'c=210 kg/cm2 | 2d | 2022-05-25 | 2022-05-26 | 84SS+1d | 85d |  |
| 84 | 1.5.2.2 | ZAPATAS.- ENCOFRADO Y DESENCOFRADO | 3d | 2022-05-24 | 2022-05-26 | 88 | 0d |  |
| 85 | 1.5.2.3 | ZAPATAS.-ACERO fy=4200 kg/cm2 | 3d | 2022-05-24 | 2022-05-26 | 84SS | 85d |  |
| 86 | 1.5.2.4 | ZAPATAS.- ENTIBADO H=1.5-2.2m | 5d | 2022-05-24 | 2022-05-28 | 84SS | 83d |  |
| 87 | 1.5.3 | **PLATEA DE CIMENTACIÓN** | 5d | 2022-05-18 | 2022-05-23 |  | 0d |  |
| 88 | 1.5.3.1 | PLATEA DE CIMENTACION.-CONCRETO f'c=210 kg/cm2 | 3d | 2022-05-20 | 2022-05-23 | 89 | 0d |  |
| 89 | 1.5.3.2 | PLATEA DE CIMENTACION.- ENCOFRADO Y DESENCOFRADO | 2d | 2022-05-18 | 2022-05-19 | 58 | 0d |  |
| 90 | 1.5.3.3 | PLATEA DE CIMENTACION.-ACERO fy=4200 kg/cm2 | 2d | 2022-05-18 | 2022-05-19 | 89SS | 91d |  |
| 91 | 1.5.4 | **VIGAS DE CIMENTACION** | 2d | 2022-05-24 | 2022-05-25 |  | 84d |  |
| 92 | 1.5.4.1 | VIGAS DE CIMENTACION.- CONCRETO fc=210kg/cm2 | 1d | 2022-05-25 | 2022-05-25 | 93 | 86d |  |
| 93 | 1.5.4.2 | VIGAS DE CIMENTACION.- ENCOFRADO Y DESENCOFRADO | 1d | 2022-05-24 | 2022-05-24 | 84SS | 86d | 0d |
| 94 | 1.5.4.3 | VIGAS DE CIMENTACION.-ACERO fy=4200 kg/cm2 | 2d | 2022-05-24 | 2022-05-25 | 93SS | 86d |  |
| 95 | 1.5.5 | **COLUMNA** | 10d | 2022-06-07 | 2022-06-17 |  | 0d |  |
| 96 | 1.5.5.1 | COLUMNAS - CONCRETO 210 KG/CM2 | 7d | 2022-06-10 | 2022-06-17 | 97SS+3d | 0d |  |
| 97 | 1.5.5.2 | COLUMNAS.- ENCOFRADO Y DESENCOFRADO | 8d | 2022-06-07 | 2022-06-15 | 79 | 0d |  |
| 98 | 1.5.5.3 | COLUMNAS.-ACERO fy=4200 kg/cm2 | 8d | 2022-06-07 | 2022-06-15 | 97SS | 68d |  |
| 99 | 1.5.6 | **VIGAS** | 23d | 2022-06-18 | 2022-07-14 |  | 0d |  |
| 100 | 1.5.6.1 | VIGAS - CONCRETO 210Kg/cm2 | 3d | 2022-07-12 | 2022-07-14 | 104 | 43d |  |
| 101 | 1.5.6.2 | VIGAS.- ENCOFRADO Y DESENCOFRADO | 7d | 2022-06-18 | 2022-06-25 | 96 | 0d |  |
| 102 | 1.5.6.3 | VIGAS.-ACERO fy=4200 kg/cm2 | 7d | 2022-06-18 | 2022-06-25 | 101SS | 59d |  |

| ID | WBS | Task | Duration | Start | Finish | Predecessors | Total slack | Free slack |
| --- | --- | --- | --- | --- | --- | --- | --- | --- |
| 103 | 1.5.7 | **LOSAS ALIGERADAS** | 14d | 2022-06-27 | 2022-07-12 |  | 0d |  |
| 104 | 1.5.7.1 | LOSA ALIGERADA - CONCRETO 210 kg/cm2 | 2d | 2022-07-09 | 2022-07-11 | 105 | 0d |  |
| 105 | 1.5.7.2 | LOSA ALIGERADA.- ENCOFRADO Y DESENCOFRADO | 11d | 2022-06-27 | 2022-07-08 | 101 | 0d |  |
| 106 | 1.5.7.3 | LOSA ALIGERADA.-ACERO fy=4200 kg/cm2 | 11d | 2022-06-27 | 2022-07-08 | 105SS | 48d |  |
| 107 | 1.5.7.4 | LOSA ALIGERADA.- LADR. HUECO 15X30X30 | 3d | 2022-07-09 | 2022-07-12 | 105 | 41d | 0d |
| 108 | 1.5.8 | **ESCALERAS** | 5d | 2022-06-18 | 2022-06-23 |  | 59d |  |
| 109 | 1.5.8.1 | ESCALERAS.- CONCRETO fc=210 kg/cm2 | 1d | 2022-06-23 | 2022-06-23 | 110 | 61d |  |
| 110 | 1.5.8.2 | ESCALERAS.- ENCOFRADO Y DESENCOFRADO | 4d | 2022-06-18 | 2022-06-22 | 96 | 61d | 0d |
| 111 | 1.5.8.3 | ESCALERAS.- ACERO fy=4200 kg/cm2 | 3d | 2022-06-18 | 2022-06-21 | 110SS | 63d |  |
| 112 | 1.5.9 | **LOSA MACISA** | 14d | 2022-06-27 | 2022-07-12 |  | 43d |  |
| 113 | 1.5.9.1 | LOSA MACISA.-CONCRETO f'c=210 kg/cm2 | 1d | 2022-07-12 | 2022-07-12 | 104 | 39d | 0d |
| 114 | 1.5.9.2 | LOSA MACISA.- ENCOFRADO Y DESENCOFRADO | 1d | 2022-06-27 | 2022-06-27 | 105SS | 55d | 0d |
| 115 | 1.5.9.3 | LOSA MACISA.-ACERO fy=4200 kg/cm2 | 4d | 2022-06-27 | 2022-06-30 | 114SS | 55d |  |
| 116 | 1.5.10 | **CUNETAS CON REJILLA** | 6d | 2022-05-05 | 2022-05-11 |  | 91d |  |
| 117 | 1.5.10.1 | CUNETAS.-CONCRETO f'c=175 kg/cm2 | 1d | 2022-05-11 | 2022-05-11 | 118 | 112d | 0d |
| 118 | 1.5.10.2 | CUNETAS.- ENCOFRADO Y DESENCOFRADO | 5d | 2022-05-05 | 2022-05-10 | 163 | 112d | 0d |
| 119 | 1.5.10.3 | CUNETAS.-ACERO fy=4200 kg/cm2 | 1d | 2022-05-05 | 2022-05-05 | 118SS | 122d |  |
| 120 | 1.5.11 | **CISTERNA** | 4d | 2022-05-25 | 2022-05-28 |  | 72d |  |
| 121 | 1.5.11.1 | CISTERNA.-CONCRETO f'c=210 kg/cm2 | 1d | 2022-05-28 | 2022-05-28 | 122 | 74d | 0d |
| 122 | 1.5.11.2 | CISTERNA.- ENCOFRADO Y DESENCOFRADO | 3d | 2022-05-25 | 2022-05-27 | 216 | 74d | 0d |
| 123 | 1.5.11.3 | CISTERNA.-ACERO fy=4200 kg/cm2 | 3d | 2022-05-25 | 2022-05-27 | 122SS | 84d |  |
| 124 | 1.5.12 | **TANQUE ELEVADO** | 2d | 2022-05-05 | 2022-05-06 |  | 100d |  |
| 125 | 1.5.12.1 | TANQUE ELEVADO.-CONCRETO f'c=210 kg/cm2 | 1d | 2022-05-06 | 2022-05-06 | 126 | 121d |  |
| 126 | 1.5.12.2 | TANQUE ELEVADO.- ENCOFRADO Y DESENCOFRADO | 1d | 2022-05-05 | 2022-05-05 | 163 | 121d | 0d |
| 127 | 1.5.12.3 | TANQUE ELEVADO.-ACERO fy=4200 kg/cm2 | 1d | 2022-05-05 | 2022-05-05 | 126SS | 122d |  |

| ID | WBS | Task | Duration | Start | Finish | Predecessors | Total slack | Free slack |
| --- | --- | --- | --- | --- | --- | --- | --- | --- |
| 128 | 1.6 | **ESTRUCTURAS METALICAS** | 10d | 2022-06-18 | 2022-06-29 |  | 54d |  |
| 129 | 1.6.1 | TIJERAL T-1(HABILITACION Y MONTAJE) | 2d | 2022-06-18 | 2022-06-20 | 96 | 56d | 0d |
| 130 | 1.6.2 | VIGUETA METALICA VG1 (HABILITACIÓN Y MONTAJE) | 3d | 2022-06-21 | 2022-06-23 | 129 | 56d | 0d |
| 131 | 1.6.3 | TEMPLADOR Y CRUZ DE SAN ANDRES | 1d | 2022-06-24 | 2022-06-24 | 130 | 56d | 0d |
| 132 | 1.6.4 | APOYOS METALICOS FIJO Y MOVIL | 2d | 2022-06-18 | 2022-06-20 | 129SS | 64d |  |
| 133 | 1.6.5 | CANALETA FG 1.6MM | 1d | 2022-06-29 | 2022-06-29 | 134 | 56d |  |
| 134 | 1.6.6 | COBERTURA LIVIANA | 3d | 2022-06-25 | 2022-06-28 | 131 | 56d | 0d |
| 135 | 2 | **ARQUITECTURA** | 102d | 2022-05-02 | 2022-08-27 |  | 3d |  |
| 136 | 2.1 | **MUROS Y TABIQUES DE ALBAÑILERIA** | 23d | 2022-06-07 | 2022-07-02 |  | 49d |  |
| 137 | 2.1.1 | MURO DE LADRILLO KK TIPO IV SOGA M : 1:1:4 e=1.5cm | 14d | 2022-06-17 | 2022-07-02 | 138 | 51d | 0d |
| 138 | 2.1.2 | MURO DE LADRILLO KK TIPO IV CABEZA M : 1:1:4 e=1.5cm | 9d | 2022-06-07 | 2022-06-16 | 79 | 51d | 0d |
| 139 | 2.1.3 | FIERRO REFUERZO HORIZONTAL EN MUROS | 1d | 2022-06-07 | 2022-06-07 | 138SS | 75d |  |
| 140 | 2.1.4 | **TABIQUERIA MOVIL** | 3d | 2022-06-17 | 2022-06-20 |  | 60d |  |
| 141 | 2.1.4.1 | MURO DE DRYWALL DOBLE ESTRUCTURA e= 1.5cm | 3d | 2022-06-17 | 2022-06-20 | 138 | 62d | 11d |
| 142 | 2.2 | **REVOQUES Y REVESTIMIENTOS** | 63d | 2022-05-30 | 2022-08-10 |  | 18d |  |
| 143 | 2.2.1 | TARRAJEO DEL TIPO RAYADO O PRIMARIO CON MORTERO 1:5 | 1d | 2022-07-12 | 2022-07-12 | 144SS | 30d | 0d |
| 144 | 2.2.2 | TARRAJEO EN MUROS INTERIORES | 7d | 2022-07-12 | 2022-07-19 | 104 | 0d |  |
| 145 | 2.2.3 | TARRAJEO EN MUROS EXTERIORES | 9d | 2022-08-01 | 2022-08-10 | 152 | 20d | 0d |
| 146 | 2.2.4 | TARRAJEO DE COLUMNAS | 12d | 2022-07-12 | 2022-07-25 | 144SS | 29d | 0d |
| 147 | 2.2.5 | TARRAJEO DE VIGAS | 7d | 2022-07-20 | 2022-07-27 | 144 | 32d |  |
| 148 | 2.2.6 | TARRAJEO CON IMPERMEABILIZANTE | 5d | 2022-05-30 | 2022-06-03 | 121 | 74d | 0d |
| 149 | 2.2.7 | VESTIDURA DE DERRAMES (1:5) | 4d | 2022-07-20 | 2022-07-23 | 144 | 35d |  |
| 150 | 2.2.8 | BRUÑAS SEGÚN DETALLE | 5d | 2022-08-05 | 2022-08-10 | 145FF | 20d |  |
| 151 | 2.3 | **CIELORRASOS** | 10d | 2022-07-20 | 2022-07-30 |  | 0d |  |
| 152 | 2.3.1 | CIELORRASO CON MEZCLA C:A 1:5 | 10d | 2022-07-20 | 2022-07-30 | 144 | 0d |  |

| ID | WBS | Task | Duration | Start | Finish | Predecessors | Total slack | Free slack |
| --- | --- | --- | --- | --- | --- | --- | --- | --- |
| 153 | 2.4 | **PISOS Y PAVIMENTOS** | 90d | 2022-05-02 | 2022-08-13 |  | 15d |  |
| 154 | 2.4.1 | **CONTRAPISOS** | 3d | 2022-06-20 | 2022-06-22 |  | 59d |  |
| 155 | 2.4.1.1 | CONTRAPISO DE 40 mm | 3d | 2022-06-20 | 2022-06-22 | 73 | 61d | 0d |
| 156 | 2.4.2 | **PISOS** | 76d | 2022-05-18 | 2022-08-13 |  | 15d |  |
| 157 | 2.4.2.1 | PISO PORCELANATO 60 x 60 MODELO DOMINE MATE BLANCO- ALTO TRANSITO | 11d | 2022-08-01 | 2022-08-12 | 152 | 3d | 0d |
| 158 | 2.4.2.2 | PISO CERAMICO 45 x 45 ALTO TRÁNSITO | 1d | 2022-08-13 | 2022-08-13 | 157 | 17d |  |
| 159 | 2.4.2.3 | PISO DE CONCRETO EN PATIOS f'c=175kg/cm2; e=15cm FROTACHADO | 2d | 2022-05-19 | 2022-05-20 | 160 | 89d | 0d |
| 160 | 2.4.2.4 | PATIOS.- ENCOFRADO Y DESENCOFRADO | 1d | 2022-05-18 | 2022-05-18 | 58 | 89d | 0d |
| 161 | 2.4.2.5 | PISO DE GOMA ECOLOGICO DE CAUCHO SUMINISTRO E INSTALACION | 1d | 2022-05-21 | 2022-05-21 | 159 | 89d |  |
| 162 | 2.4.3 | **VEREDAS Y RAMPAS** | 4d | 2022-05-02 | 2022-05-05 |  | 91d |  |
| 163 | 2.4.3.1 | VEREDAS e=4" DE CONCRETO f'c=175kg/cm2 ACABADO FROTACHADO Y BRUÑADO | 2d | 2022-05-03 | 2022-05-04 | 165 | 112d | 0d |
| 164 | 2.4.3.2 | RAMPAS e=4" DE CONCRETO f'c=175kg/cm2 ACABADO FROTACHADO Y BRUÑADO | 1d | 2022-05-05 | 2022-05-05 | 163 | 122d | 0d |
| 165 | 2.4.3.3 | VEREDAS Y RAMPAS.- ENCOFRADO Y DESENCOFRADO | 1d | 2022-05-02 | 2022-05-02 |  | 112d | 0d |
| 166 | 2.5 | **ZOCALOS Y CONTRAZÓCALOS** | 40d | 2022-07-13 | 2022-08-27 |  | 3d |  |
| 167 | 2.5.1 | **ZOCALOS** | 6d | 2022-07-13 | 2022-07-19 |  | 28d |  |
| 168 | 2.5.1.1 | ZOCALO CERAMICO 45X45 | 6d | 2022-07-13 | 2022-07-19 | 143 | 30d | 0d |
| 169 | 2.5.2 | **CONTRAZOCALOS** | 13d | 2022-08-13 | 2022-08-27 |  | 3d |  |
| 170 | 2.5.2.1 | CONTRAZOCALO DE PORCELANATO 20X60 MODELO POTENSA BLANCO PERLA MATE-ALTO TRANSITO | 6d | 2022-08-13 | 2022-08-19 | 157 | 3d | 0d |
| 171 | 2.5.2.2 | CONTRAZOCALO PORCELANATO 10 x 60 MODELO POTENSA BLANCO PERLA MATE- ALTO TRANSITO | 7d | 2022-08-20 | 2022-08-27 | 170 | 3d |  |
| 172 | 2.6 | **COBERTURAS** | 9d | 2022-07-12 | 2022-07-21 |  | 33d |  |
| 173 | 2.6.1 | COBERTURA CON PLANCHA CALAMINON TAT 1060 TERMO-AISLANTE e=25mm (INC. ESTRUCTURA DE SOPORTE METALICA) | 9d | 2022-07-12 | 2022-07-21 | 104 | 35d | 0d |
| 174 | 2.7 | **CARPINTERIA DE MADERA** | 9d | 2022-08-15 | 2022-08-24 |  | 3d |  |
| 175 | 2.7.1 | PUERTA MACHIEMBRADA | 5d | 2022-08-15 | 2022-08-19 | 202 | 3d | 0d |
| 176 | 2.7.2 | PUERTA CONTRAPLACADA 40 mm CON TRIPLAY 6 mm INCLUYE MARCO CEDRO 2"x4" | 4d | 2022-08-20 | 2022-08-24 | 175 | 3d | 0d |
| 177 | 2.7.3 | PIZARRA ACRILICA | 4d | 2022-08-15 | 2022-08-18 | 202 | 11d |  |

| ID | WBS | Task | Duration | Start | Finish | Predecessors | Total slack | Free slack |
| --- | --- | --- | --- | --- | --- | --- | --- | --- |
| 178 | 2.8 | **CARPINTERIA METALICA Y HERRERÍA** | 90d | 2022-05-05 | 2022-08-17 |  | 12d |  |
| 179 | 2.8.1 | CANTONERA DE FIERRO EN ESCALERA | 3d | 2022-08-13 | 2022-08-16 | 157 | 14d | 0d |
| 180 | 2.8.2 | PUERTAS DE INGRESOS PRINCIPALES | 5d | 2022-07-26 | 2022-07-30 | 146 | 29d |  |
| 181 | 2.8.3 | ASTA DE BANDERA | 1d | 2022-05-21 | 2022-05-21 | 159 | 89d |  |
| 182 | 2.8.4 | BARANDA METALICA EN ESCALERA | 1d | 2022-08-17 | 2022-08-17 | 179 | 14d |  |
| 183 | 2.8.5 | REJILLA METALICA PARA CUNETA DE 1"X1"X1/8" (INCLUYE COLOCACION) | 5d | 2022-05-12 | 2022-05-17 | 117 | 112d |  |
| 184 | 2.8.6 | SUMINISTRO E INSTALACION DE ENCUENTRO METALICO ENTRE SOBRETECHO Y PARAPETO | 4d | 2022-07-12 | 2022-07-15 | 173SS | 42d |  |
| 185 | 2.8.7 | SUMINISTRO E INSTALACION DE CANALETA DE EVACUACION PLUVIAL 610 mm | 2d | 2022-07-22 | 2022-07-23 | 173 | 35d |  |
| 186 | 2.8.8 | BATERIAS ECOLOGICAS DE TRES TACHOS | 2d | 2022-05-05 | 2022-05-06 | 163 | 121d |  |
| 187 | 2.8.9 | ESCALERA DE GATO DE FIERRO GALVANIZADO | 2d | 2022-06-04 | 2022-06-06 | 148 | 76d |  |
| 188 | 2.8.10 | ESCALERA DE ALUMINIO EN CISTERNA | 1d | 2022-06-04 | 2022-06-04 | 148 | 77d |  |
| 189 | 2.8.11 | PUERTA DE CASETA DE ELECTROBOMBA | 1d | 2022-06-04 | 2022-06-04 | 148 | 76d | 0d |
| 190 | 2.8.12 | TUBOS METÁLICOS EN CERCO PERIMÉTRICO | 4d | 2022-07-26 | 2022-07-29 | 146 | 29d | 0d |
| 191 | 2.8.13 | CERCO METÁLICO C/TUB. RED. 2", ANG. 1" Y MALLA 2"X2"#12 | 1d | 2022-06-17 | 2022-06-17 | 138 | 65d | 36d |
| 192 | 2.9 | **VENTANAS DE ALUMINIO CON PROTECTOR, CRISTAL Y VIDRIOS** | 10d | 2022-08-15 | 2022-08-25 |  | 5d |  |
| 193 | 2.9.1 | SUMINISTRO E INSTALACION DE VENTANA DE ALUMINIO CON CRISTAL CRUDO DE 6 mm INCOLORO + LAMINA DE SEGURIDAD DE 4 MICRAS Y PROTECTOR DE SEGURIDAD | 10d | 2022-08-15 | 2022-08-25 | 202 | 5d |  |
| 194 | 2.10 | **CERRAJERIA** | 71d | 2022-06-06 | 2022-08-26 |  | 4d |  |
| 195 | 2.10.1 | BISAGRA ALUMINIZADA DE 4" PESADA EN PUERTAS | 5d | 2022-08-20 | 2022-08-25 | 175 | 5d |  |
| 196 | 2.10.2 | BISAGRA ALUMINIZADA DE 3" PESADA EN PUERTAS | 1d | 2022-08-25 | 2022-08-25 | 176 | 5d |  |
| 197 | 2.10.3 | CERRADURA TRES GOLPES CON TIRADOR EN PUERTAS | 2d | 2022-08-25 | 2022-08-26 | 176 | 4d |  |
| 198 | 2.10.4 | CHAPA DE POMO CON PESTILLO EN PUERTA | 1d | 2022-08-25 | 2022-08-25 | 176 | 5d |  |
| 199 | 2.10.5 | CANDADO DE 60mm | 1d | 2022-06-06 | 2022-06-06 | 189 | 76d |  |
| 200 | 2.11 | **PINTURA** | 25d | 2022-07-30 | 2022-08-27 |  | 1d |  |
| 201 | 2.11.1 | PINTURA LATEX 2 MANOS EN MUROS Y COLUMNAS | 9d | 2022-08-01 | 2022-08-10 | 152 | 0d |  |
| 202 | 2.11.2 | PINTURA LATEX 2 MANOS EN CIELO RASO Y VIGAS | 3d | 2022-08-11 | 2022-08-13 | 201 | 0d |  |
| 203 | 2.11.3 | PINTURA ANTICORROSIVA Y ESMALTE 2 MANOS DE CARPINTERIA METALICA | 1d | 2022-07-30 | 2022-07-30 | 190, 191 | 29d |  |
| 204 | 2.11.4 | PINTURA EN PUERTAS DE MADERA | 3d | 2022-08-25 | 2022-08-27 | 176 | 3d |  |

| ID | WBS | Task | Duration | Start | Finish | Predecessors | Total slack | Free slack |
| --- | --- | --- | --- | --- | --- | --- | --- | --- |
| 205 | 2.12 | **JUNTAS** | 15d | 2022-05-05 | 2022-05-21 |  | 87d |  |
| 206 | 2.12.1 | JUNTA DE DILATACION EN PISOS CON TECNOPORT DE e= 3/8" RELLENO CON POLIURETANO | 1d | 2022-05-21 | 2022-05-21 | 159 | 89d |  |
| 207 | 2.12.2 | JUNTAS ASFALTICAS e=1" | 1d | 2022-05-05 | 2022-05-05 | 163 | 122d |  |
| 208 | 2.13 | **VARIOS** | 90d | 2022-05-04 | 2022-08-16 |  | 13d |  |
| 209 | 2.13.1 | CURADO CON CURADOR QUIMICO PARA CONCRETO | 2d | 2022-05-04 | 2022-05-05 | 164FF | 122d |  |
| 210 | 2.13.2 | SUMINISTRO E INSTALACION DE STICKER PARA SEÑALITICA DE SEGURIDAD | 1d | 2022-08-11 | 2022-08-11 | 201 | 19d |  |
| 211 | 2.13.3 | SUMINISTRO E INSTALACION DE EXTINTOR DE POLVO QUIMICO SECO | 1d | 2022-08-11 | 2022-08-11 | 201 | 17d |  |
| 212 | 2.13.4 | SUMINISTRO E INSTALACION DE JUEGOS INFANTILES | 5d | 2022-08-11 | 2022-08-16 | 201 | 13d |  |
| 213 | 3 | **INSTALACIONES SANITARIAS** | 91d | 2022-05-02 | 2022-08-15 |  | 14d |  |
| 214 | 3.1 | **MOVIMIENTO DE TIERRAS** | 23d | 2022-05-18 | 2022-06-13 |  | 68d |  |
| 215 | 3.1.1 | EXCAVACION DE ZANJAS PARA H=0.80m, PARA TUBERIA DE 160 Y 200 mm | 1d | 2022-05-18 | 2022-05-18 | 58 | 68d | 0d |
| 216 | 3.1.2 | EXCAVACION DE ZANJAS MANUAL H<=3.00m | 5d | 2022-05-19 | 2022-05-24 | 215 | 72d | 0d |
| 217 | 3.1.3 | RELLENO C/ARENA HASTA e=0.20m LA CLAVE PARA TUBO DE 160 Y 200 mm | 4d | 2022-06-04 | 2022-06-08 | 262 | 68d | 0d |
| 218 | 3.1.4 | RELLENO Y COMPACTACION DE ZANJAS C/ MATERIAL PROPIO CON EQUIPO H=0.8m | 4d | 2022-06-09 | 2022-06-13 | 217 | 68d |  |
| 219 | 3.1.5 | REFINE, NIVELACION DE ZANJAS P/TUBO DE 160 Y 200 mm | 2d | 2022-05-19 | 2022-05-20 | 215 | 68d | 0d |
| 220 | 3.1.6 | CAMA DE ARENA GRUESA e=0.10m PARA TUBO DE 160 Y 200 mm | 2d | 2022-05-21 | 2022-05-23 | 219 | 86d |  |
| 221 | 3.2 | **SISTEMA DE AGUA POTABLE EXTERIOR** | 46d | 2022-05-21 | 2022-07-13 |  | 42d |  |
| 222 | 3.2.1 | TUBERIA PVC-SAP 2" CLASE 10 | 1d | 2022-05-21 | 2022-05-21 | 219 | 68d | 0d |
| 223 | 3.2.2 | TUBERIA PVC-SAP 1" CLASE 10 | 1d | 2022-05-23 | 2022-05-23 | 222 | 68d | 0d |
| 224 | 3.2.3 | TUBERIA PVC-SAP 3/4" CLASE 10 | 1d | 2022-05-24 | 2022-05-24 | 223 | 68d | 0d |
| 225 | 3.2.4 | VALVULA TIPO BOLA 1 1/2" | 1d | 2022-05-26 | 2022-05-26 | 226 | 83d |  |
| 226 | 3.2.5 | CAJA PREFABRICADA P/VALVULAS | 1d | 2022-05-25 | 2022-05-25 | 224 | 83d | 0d |
| 227 | 3.2.6 | SUMINISTRO E INSTALACION DE TANQUE DE AGUA DE POLIETILENO (2,500L) | 1d | 2022-07-13 | 2022-07-13 | 113 | 37d | 0d |
| 228 | 3.3 | **SISTEMA DE DESAGUE EXTERIOR** | 4d | 2022-05-21 | 2022-05-25 |  | 79d |  |
| 229 | 3.3.1 | TUBERIA DE PVC SAL 4" | 1d | 2022-05-21 | 2022-05-21 | 219 | 79d | 0d |
| 230 | 3.3.2 | SUMINISTRO E INSTALACION DE TUBERIA PVC 160mm ISO 4435 S-20 | 1d | 2022-05-23 | 2022-05-23 | 229 | 86d |  |
| 231 | 3.3.3 | CAJA DE REGISTRO PREFABRICADA DE 12" X 24" CON TAPA DE CONCRETO | 4d | 2022-05-21 | 2022-05-25 | 219 | 84d |  |
| 232 | 3.3.4 | CAJA DE REGISTRO DE ALBAÑILERIA DE 24" X 24" CON TAPA DE CONCRETO | 1d | 2022-05-21 | 2022-05-21 | 219 | 87d |  |
| 233 | 3.3.5 | SUMINISTRO E INSTALACION DE BIODIGESTOR | 1d | 2022-05-25 | 2022-05-25 | 216 | 84d |  |

| ID | WBS | Task | Duration | Start | Finish | Predecessors | Total slack | Free slack |
| --- | --- | --- | --- | --- | --- | --- | --- | --- |
| 234 | 3.4 | **PRUEBA HIDRAULICA DE CISTERNA, TANQUE Y SISTEMA DE BOMBEO** | 2d | 2022-06-04 | 2022-06-06 |  | 74d |  |
| 235 | 3.4.1 | PRUEBA HIDRAULICA DE CISTERNA Y EQUIPO DE BOMBEO | 2d | 2022-06-04 | 2022-06-06 | 148 | 74d |  |
| 236 | 3.5 | **APARATOS SANITARIOS Y ACCESORIOS** | 51d | 2022-06-17 | 2022-08-15 |  | 14d |  |
| 237 | 3.5.1 | INODORO TANQUE BAJO DE LOSA INCLUYE ACCESORIOS | 3d | 2022-07-20 | 2022-07-22 | 168 | 28d | 0d |
| 238 | 3.5.2 | URINARIOS DE LOZA DE PICO | 1d | 2022-07-23 | 2022-07-23 | 237 | 28d | 0d |
| 239 | 3.5.3 | LAVATORIO DE LOZA BLANCA | 1d | 2022-07-25 | 2022-07-25 | 238 | 28d | 0d |
| 240 | 3.5.4 | LAVATORIO CORRIDO SEGUN DISEÑO REV.C/CERÁMICA 30X30 | 1d | 2022-06-17 | 2022-06-17 | 138 | 60d | 32d |
| 241 | 3.5.5 | DISPENSADOR DE JABON LIQUIDO | 1d | 2022-07-26 | 2022-07-26 | 239, 240 | 28d | 0d |
| 242 | 3.5.6 | PAPELERA DE CERAMICA | 1d | 2022-07-27 | 2022-07-27 | 241 | 28d | 0d |
| 243 | 3.5.7 | TRAMPA DE GRASA TIPO HEVEX MODELO IG-20 | 1d | 2022-06-23 | 2022-06-23 | 155 | 59d |  |
| 244 | 3.5.8 | ESPEJO BISELADO | 1d | 2022-08-15 | 2022-08-15 | 202 | 14d |  |
| 245 | 3.5.9 | PAPELERA PLASTICA | 1d | 2022-07-28 | 2022-07-28 | 242 | 28d | 0d |
| 246 | 3.5.10 | LAVADERO DE ACERO INOXIDABLE | 1d | 2022-07-29 | 2022-07-29 | 245 | 28d |  |
| 247 | 3.5.11 | MESA CORRIDA DE CONCRETO REVEST. C/CERÁMICO | 2d | 2022-07-04 | 2022-07-05 | 137, 141 | 49d |  |
| 248 | 3.6 | **INSTALACIONES SANITARIAS DE DESAGUE** | 8d | 2022-05-23 | 2022-05-31 |  | 79d |  |
| 249 | 3.6.1 | SALIDA DE DESAGUE EN PVC | 5d | 2022-05-23 | 2022-05-27 | 229 | 79d | 0d |
| 250 | 3.6.2 | SALIDA PARA VENTILACION | 3d | 2022-05-28 | 2022-05-31 | 249 | 79d |  |
| 251 | 3.6.3 | TUBERIA PVC-SAL 2" | 3d | 2022-05-25 | 2022-05-27 | 252 | 80d | 0d |
| 252 | 3.6.4 | TUBERIA PVC-SAL 4" | 2d | 2022-05-23 | 2022-05-24 | 229 | 80d | 0d |
| 253 | 3.6.5 | REGISTROS DE BRONCE DE 4" | 2d | 2022-05-25 | 2022-05-26 | 252 | 83d |  |
| 254 | 3.6.6 | REGISTROS DE BRONCE DE 2" | 1d | 2022-05-28 | 2022-05-28 | 251 | 80d | 0d |
| 255 | 3.6.7 | PRUEBA HIDRAULICA Y ESCORRENTIA TUB. DESAGUE | 1d | 2022-05-30 | 2022-05-30 | 254 | 80d |  |
| 256 | 3.7 | **INSTALACIONES SANITARIAS DE AGUA** | 9d | 2022-05-25 | 2022-06-03 |  | 68d |  |
| 257 | 3.7.1 | SALIDA DE AGUA FRIA.- PVC | 5d | 2022-05-25 | 2022-05-30 | 224 | 68d | 0d |
| 258 | 3.7.2 | TUBERIA PVC CLASE 10 - 1/2" ROSCADA | 1d | 2022-05-31 | 2022-05-31 | 257 | 68d | 0d |
| 259 | 3.7.3 | TUBERIA PVC CLASE 10 - 3/4" ROSCADA | 1d | 2022-06-01 | 2022-06-01 | 258 | 68d | 0d |
| 260 | 3.7.4 | VALVULA DE COMPUERTA DE BRONCE 3/4" | 1d | 2022-06-03 | 2022-06-03 | 261 | 76d |  |
| 261 | 3.7.5 | CAJA DE MADERA PARA VALVULA | 1d | 2022-06-02 | 2022-06-02 | 259 | 68d | 0d |
| 262 | 3.7.6 | PRUEBA HIDRAULICA EN TUBERIA DE AGUA | 1d | 2022-06-03 | 2022-06-03 | 261 | 68d | 0d |

| ID | WBS | Task | Duration | Start | Finish | Predecessors | Total slack | Free slack |
| --- | --- | --- | --- | --- | --- | --- | --- | --- |
| 263 | 3.8 | **TUBERIAS Y ACCESORIOS TANQUE ELEVADO** | 39d | 2022-06-04 | 2022-07-19 |  | 37d |  |
| 264 | 3.8.1 | TUBERIA FIERRO GALVANIZADO 3" | 1d | 2022-07-14 | 2022-07-14 | 227 | 37d | 0d |
| 265 | 3.8.2 | TUBERIA DE PVC SAP 2" CLASE 10 | 1d | 2022-07-15 | 2022-07-15 | 264 | 37d | 0d |
| 266 | 3.8.3 | TUBERIA DE PVC SAP 2 1/2" CLASE 10 | 1d | 2022-07-16 | 2022-07-16 | 265 | 37d | 0d |
| 267 | 3.8.4 | TUBERIA FIERRO GALVANIZADO 2" | 1d | 2022-07-15 | 2022-07-15 | 265SS | 40d |  |
| 268 | 3.8.5 | TUBERIA FIERRO GALVANIZADO 1 1/2" | 1d | 2022-07-18 | 2022-07-18 | 266 | 37d | 0d |
| 269 | 3.8.6 | TUBERIA PVC CLASE 10 - 1/2" ROSCADA | 1d | 2022-07-19 | 2022-07-19 | 268 | 37d | 0d |
| 270 | 3.8.7 | VALVULA CHECK 2" | 1d | 2022-07-15 | 2022-07-15 | 265SS | 40d |  |
| 271 | 3.8.8 | VALVULA CHECK 1 1/2" | 1d | 2022-07-18 | 2022-07-18 | 268SS | 38d |  |
| 272 | 3.8.9 | VALVULA DE COMPUERTA DE BRONCE 2" | 1d | 2022-07-15 | 2022-07-15 | 265SS | 40d |  |
| 273 | 3.8.10 | VALVULA DE COMPUERTA DE BRONCE 1 1/2" | 1d | 2022-07-18 | 2022-07-18 | 268SS | 38d |  |
| 274 | 3.8.11 | VALVULA DE COMPUERTA DE BRONCE 1/2" | 1d | 2022-07-19 | 2022-07-19 | 269SS | 37d |  |
| 275 | 3.8.12 | VALVULA FLOTADORA 1 1/2" | 1d | 2022-07-18 | 2022-07-18 | 268SS | 37d | 0d |
| 276 | 3.8.13 | VALVULA FLOTADORA 3/4" | 1d | 2022-07-19 | 2022-07-19 | 275 | 37d |  |
| 277 | 3.8.14 | CAJA BAYPAS DE CONCRETO | 1d | 2022-07-14 | 2022-07-14 | 264SS | 41d |  |
| 278 | 3.8.15 | CAJA DE REBOSE CON REJILLA METALICA | 1d | 2022-07-14 | 2022-07-14 | 264SS | 41d |  |
| 279 | 3.8.16 | SUMINISTRO E INSTALACION DE EQUIPO DE BOMBEO | 1d | 2022-07-14 | 2022-07-14 | 264SS | 41d |  |
| 280 | 3.8.17 | TAPA DE FIERRO EN CISTERNA | 1d | 2022-06-04 | 2022-06-04 | 148 | 72d | 0d |
| 281 | 3.8.18 | REBOSE DE TANQUE ALTO FIERRO GALVAN. 2" | 1d | 2022-06-06 | 2022-06-06 | 280 | 74d |  |
| 282 | 3.8.19 | REBOSE DE CISTERNA DE FIERRO GALVANIZADA 4" | 1d | 2022-06-06 | 2022-06-06 | 280 | 72d | 0d |
| 283 | 3.8.20 | ABRAZADERA DE FIJACION DE TUBO | 1d | 2022-06-07 | 2022-06-07 | 282 | 72d | 0d |
| 284 | 3.8.21 | ROMPE AGUA | 1d | 2022-06-08 | 2022-06-08 | 283 | 72d |  |
| 285 | 3.9 | **SISTEMA DE DRENAJE PLUVIAL** | 43d | 2022-05-02 | 2022-06-20 |  | 62d |  |
| 286 | 3.9.1 | TUBERIA DE BAJADA Y RED PVC SAP 110 mm | 2d | 2022-06-18 | 2022-06-20 | 96 | 62d |  |
| 287 | 3.9.2 | SUMINISTRO E INSTALACION TUBERIA PVC 200mm ISO 4435 S-20 | 1d | 2022-05-02 | 2022-05-02 | 165SS | 104d | 0d |
| 288 | 3.9.3 | CAJA DE REGISTRO PREFABRICADA DE 18" X 24" CON TAPA DE CONCRETO | 1d | 2022-05-02 | 2022-05-02 | 287SS | 104d |  |

| ID | WBS | Task | Duration | Start | Finish | Predecessors | Total slack | Free slack |
| --- | --- | --- | --- | --- | --- | --- | --- | --- |
| 289 | 3.10 | **RECONEXION A LAS REDES EXISTENTES** | 1d | 2022-05-21 | 2022-05-21 |  | 87d |  |
| 290 | 3.10.1 | EMPALME A RED EXISTENTE, AGUA | 1d | 2022-05-21 | 2022-05-21 | 222SS | 87d |  |
| 291 | 4 | **INSTALACIONES ELECTRICAS** | 98d | 2022-05-04 | 2022-08-25 |  | 5d |  |
| 292 | 4.1 | **MOVIMIENTO DE TIERRAS** | 52d | 2022-05-18 | 2022-07-16 |  | 39d |  |
| 293 | 4.1.1 | EXCAVACION MANUAL DE ZANJAS PARA CABLE ELECTRICO DE 100 x 100 cm | 4d | 2022-05-18 | 2022-05-21 | 58 | 83d | 0d |
| 294 | 4.1.2 | REFINE, NIVELACION DE ZANJAS INCLUYE CAMA DE 100 CM | 1d | 2022-05-23 | 2022-05-23 | 293 | 86d |  |
| 295 | 4.1.3 | RELLENO Y COMPACTACION MANUAL DE ZANJAS C/ MATERIAL PROPIO CON EQUIPO 100 x 100 cm | 4d | 2022-07-13 | 2022-07-16 | 308 | 39d |  |
| 296 | 4.2 | **CONDUCTORES, DUCTOS Y ACCESORIOS** | 44d | 2022-05-23 | 2022-07-12 |  | 43d |  |
| 297 | 4.2.1 | CONDUCTOR DE Cu DE 1-1x10mm2 N2XOH BLANCO | 1d | 2022-07-12 | 2022-07-12 | 107FF | 43d |  |
| 298 | 4.2.2 | CONDUCTOR DE Cu DE 2.5 mm2 NH-80 VERDE | 2d | 2022-07-11 | 2022-07-12 | 107FF | 43d |  |
| 299 | 4.2.3 | CONDUCTOR DE Cu DE 2.5 mm2 NH-80 BLANCO | 4d | 2022-07-08 | 2022-07-12 | 107FF | 43d |  |
| 300 | 4.2.4 | CONDUCTOR DE Cu DE 2.5 mm2 NH-80 NEGRO | 4d | 2022-07-08 | 2022-07-12 | 107FF | 43d |  |
| 301 | 4.2.5 | CONDUCTOR DE Cu DE 4 mm2 NH-80 BLANCO | 1d | 2022-07-12 | 2022-07-12 | 107FF | 43d |  |
| 302 | 4.2.6 | CONDUCTOR DE Cu DE 4 mm2 NH-80 NEGRO | 1d | 2022-07-12 | 2022-07-12 | 107FF | 43d |  |
| 303 | 4.2.7 | CONDUCTOR DE Cu DE 4 mm2 NH-80 VERDE | 1d | 2022-07-12 | 2022-07-12 | 107FF | 43d |  |
| 304 | 4.2.8 | CONDUCTOR DE Cu DE 10 mm2 NH-80 VERDE | 1d | 2022-07-12 | 2022-07-12 | 107FF | 43d |  |
| 305 | 4.2.9 | CONDUCTOR DE Cu DESNUDO DE 35mm2 | 1d | 2022-07-12 | 2022-07-12 | 107FF | 43d |  |
| 306 | 4.2.10 | TUBERIA PVC-SAP DE 20 MM DE DIAMETRO INC. ACCESORIOS | 4d | 2022-07-08 | 2022-07-12 | 107FF | 43d |  |
| 307 | 4.2.11 | TUBERIA PVC-SAP DE 25 MM DE DIAMETRO INC. ACCESORIOS | 1d | 2022-07-12 | 2022-07-12 | 107FF | 43d |  |
| 308 | 4.2.12 | TUBERIA PVC-SAP DE 35 MM DE DIAMETRO INC. ACCESORIOS | 1d | 2022-07-12 | 2022-07-12 | 107FF | 39d | 0d |
| 309 | 4.2.13 | CAJA DE DERIVACION DE 200x200x150 | 1d | 2022-05-23 | 2022-05-23 | 293 | 86d |  |
| 310 | 4.2.14 | SISTEMA DE TUBERIA CONDUIT EMT INC. ACCESORIOS | 5d | 2022-07-07 | 2022-07-12 | 107FF | 43d |  |
| 311 | 4.3 | **ARTEFACTOS DE ILUMINACION - LUMINARIAS / TOMACORRIENTES** | 40d | 2022-07-11 | 2022-08-25 |  | 5d |  |
| 312 | 4.3.1 | SmartLED Office W60L60 - PHILLIPS (LUMINARIA ADOSADA) 4 LAMPARAS | 3d | 2022-08-11 | 2022-08-13 | 201 | 5d | 0d |
| 313 | 4.3.2 | SmartLED Office W30L120 - PHILLIPS (LUMINARIA ADOSADA) 2 LAMPARAS | 2d | 2022-08-15 | 2022-08-16 | 312 | 5d | 0d |
| 314 | 4.3.3 | INDIKO FORYIMO LED - PHILLIPS (LUMINARIA HERMÉTICA) 2 LAMPARA | 2d | 2022-08-17 | 2022-08-18 | 313 | 5d | 0d |
| 315 | 4.3.4 | BERYL ADOSADA LED 15W | 1d | 2022-08-19 | 2022-08-19 | 314 | 5d | 0d |
| 316 | 4.3.5 | LAMPARA DE EMERGENCIA DE 24 LEDS | 1d | 2022-08-20 | 2022-08-20 | 315 | 5d | 0d |
| 317 | 4.3.6 | Reflector Josfel Hall Ligth Led 250W asimétrico o EQUIVALENTE | 2d | 2022-08-22 | 2022-08-23 | 316 | 5d | 0d |
| 318 | 4.3.7 | DICROICO PARA PISO | 2d | 2022-08-24 | 2022-08-25 | 317 | 5d |  |
| 319 | 4.3.8 | CAJA OCTOGONAL F°G° DE 100mm x 55mm | 2d | 2022-07-11 | 2022-07-12 | 107FF | 43d |  |
| 320 | 4.3.9 | INTERRUPTOR SIMPLE UNIPOLAR | 1d | 2022-08-15 | 2022-08-15 | 202 | 9d | 0d |
| 321 | 4.3.10 | INTERRUPTOR DOBLE UNIPOLAR | 1d | 2022-08-16 | 2022-08-16 | 320 | 9d | 0d |
| 322 | 4.3.11 | INTERRUPTOR TRIPLE UNIPOLAR | 1d | 2022-08-17 | 2022-08-17 | 321 | 9d | 0d |
| 323 | 4.3.12 | INTERRUPTOR DE CONMUTACION SIMPLE | 1d | 2022-08-18 | 2022-08-18 | 322 | 9d | 0d |
| 324 | 4.3.13 | TOMACORRIENTE DOBLE C/T | 1d | 2022-08-19 | 2022-08-19 | 323 | 9d | 0d |
| 325 | 4.3.14 | CAJA RECTANGULAR F°G° DE 100 x 55 x 50mm | 1d | 2022-07-12 | 2022-07-12 | 107FF | 43d |  |
| 326 | 4.3.15 | TIMBRE (CHICHARRA) + PULSADOR | 1d | 2022-08-20 | 2022-08-20 | 324 | 9d |  |

| ID | WBS | Task | Duration | Start | Finish | Predecessors | Total slack | Free slack |
| --- | --- | --- | --- | --- | --- | --- | --- | --- |
| 327 | 4.4 | **TABLERO ELECTRICO TRIFASICO/ MONOFASICO** | 2d | 2022-08-11 | 2022-08-12 |  | 15d |  |
| 328 | 4.4.1 | TABLERO ELECTRICO DE F°G° EMPOTRADO 8 POLOS | 1d | 2022-08-11 | 2022-08-11 | 201 | 15d | 0d |
| 329 | 4.4.2 | TABLERO ELECTRICO DE F°G° EMPOTRADO 18 POLOS | 1d | 2022-08-12 | 2022-08-12 | 328 | 15d | 0d |
| 330 | 4.5 | **INTERRUPTORES TERMOMAGNETICOS MONOFASICOS** | 1d | 2022-08-12 | 2022-08-12 |  | 16d |  |
| 331 | 4.5.1 | INTERRUPTOR THERMOMAGNETICO MONOFASICO 2 X 15A | 1d | 2022-08-12 | 2022-08-12 | 328 | 16d |  |
| 332 | 4.5.2 | INTERRUPTOR THERMOMAGNETICO MONOFASICO 2 X 35A | 1d | 2022-08-12 | 2022-08-12 | 328 | 16d |  |
| 333 | 4.6 | **INTERRUPTORES DIFERENCIALES** | 1d | 2022-08-13 | 2022-08-13 |  | 15d |  |
| 334 | 4.6.1 | INTERRUPTOR DIFERENCIAL 2x20 A/30mm A | 1d | 2022-08-13 | 2022-08-13 | 329 | 15d |  |
| 335 | 4.6.2 | INTERRUPTOR DIFERENCIAL 2x25 A/30mm A | 1d | 2022-08-13 | 2022-08-13 | 329 | 15d |  |
| 336 | 4.7 | **CIRCUITOS DE MANDO DE ILUMINACION DE PATIOS** | 1d | 2022-08-13 | 2022-08-13 |  | 15d |  |
| 337 | 4.7.1 | PULSADOR LUMINOSO NA 220V IP66 | 1d | 2022-08-13 | 2022-08-13 | 329 | 15d |  |
| 338 | 4.7.2 | CONTACTOR TRIFASICO 25A | 1d | 2022-08-13 | 2022-08-13 | 329 | 15d |  |
| 339 | 4.8 | **PUESTA A TIERRA DE TABLERO GENERAL** | 4d | 2022-05-23 | 2022-05-26 |  | 83d |  |
| 340 | 4.8.1 | POZO CONEXION A TIERRA | 4d | 2022-05-23 | 2022-05-26 | 293 | 83d |  |
| 341 | 4.9 | **BUZON ELECTRICO** | 1d | 2022-05-23 | 2022-05-23 |  | 86d |  |
| 342 | 4.9.1 | BUZON DEL SISTEMA ELECTRICO 1.00x1.00x0.8 | 1d | 2022-05-23 | 2022-05-23 | 293 | 86d |  |
| 343 | 4.10 | **ELECTROBOMBA** | 1d | 2022-08-13 | 2022-08-13 |  | 15d |  |
| 344 | 4.10.1 | TABLERO DE ELECTROBOMBAS | 1d | 2022-08-13 | 2022-08-13 | 329 | 15d |  |
| 345 | 4.11 | **TRANSPORTE DE MATERIALES** | 1d | 2022-05-04 | 2022-05-04 |  | 102d |  |
| 346 | 4.11.1 | TRANSPORTE DE MATERIALES (3% DE MATERIALES) | 1d | 2022-05-04 | 2022-05-04 | 3 | 102d |  |
| 347 | 4.12 | **COMUNICACIONES** | 2d | 2022-05-23 | 2022-05-24 |  | 85d |  |
| 348 | 4.12.1 | TUBERIA PVC-SAP DE 25 MM DE DIAMETRO INC. ACCESORIOS | 1d | 2022-05-23 | 2022-05-23 | 293 | 86d |  |
| 349 | 4.12.2 | CAJA DE DERIVACION DE 200x200x150 | 1d | 2022-05-23 | 2022-05-23 | 293 | 85d | 0d |
| 350 | 4.12.3 | CAJA RECTANGULAR F°G° DE 100 x 55 x 50mm | 1d | 2022-05-24 | 2022-05-24 | 349 | 85d |  |

| ID | WBS | Task | Duration | Start | Finish | Predecessors | Total slack |
| --- | --- | --- | --- | --- | --- | --- | --- |
| 351 | 4.13 | **CONEXION Y ADECUACION A RED DE ENERGIA EXISTENTE** | 4d | 2022-07-13 | 2022-07-16 |  | 39d |
| 352 | 4.13.1 | CONEXION Y ADECUACION A RED DE ENERGIA EXISTENTE (incluye todas las gestiones necesarias) | 4d | 2022-07-13 | 2022-07-16 | 107 | 39d |
| 353 | 5 | CONTINGENCIA | 10d | 2022-05-02 | 2022-05-12 | 3SS | 95d |
| 354 | 6 | MOBILIARIO Y EQUIPAMIENTO | 15d | 2022-08-15 | 2022-08-31 | 202 | 0d |
